# aikataulu_0_4

Schedule from MS Project, 2010-01-01 to 2012-05-31.
HKIAMK

## Calendars

- Standard: Mon-Fri 08:00-12:00, 13:00-17:00; Sat-Sun off. Exceptions (off unless hours are given): 2010-12-06, 2011-12-06.

## Resources

| Resource |
| --- |
| Ohjausryhmä |
| Eduix |
| Ekholm |
| Rannila |
| Asiantuntijatyöryhmät |
| Projektiryhmä |
| Asiantuntijatyöryhmät, Projektiryhmä |
| Muut asiantuntijat |
| Tiedonhallinta- ja järjestelmäpalvelut |
| Koordinaatioryhmä |
| Projektipäällikkö |
| Tietohallintojohtaja |
| Rehtori |
| Eduix koodaajat |

## Schedule

| ID | WBS | Task | Type | Duration | Start | Finish | Predecessors | Total slack | Free slack | Constraint | Resources | Work |
| --- | --- | --- | --- | --- | --- | --- | --- | --- | --- | --- | --- | --- |
| 1 | 1 | **TOISU III** |  | 628d? | 2010-01-01 | 2012-05-31 |  | 0d |  |  |  | 20648h |
| 2 | 1.1 | **1. Vaihe** |  | 195d? | 2010-01-01 | 2010-09-30 |  | 433d |  |  |  | 7784h |
| 3 | 1.1.1 | **Projektisuunnitelma** |  | 31d? | 2010-01-01 | 2010-02-12 |  | 597d |  |  | Projektipäällikkö | 848h |
| 4 | 1.1.1.1 | Aikataulu |  | 18d? | 2010-01-01 | 2010-01-26 |  | 607d | 0d | finish no earlier than 2010-01-26 | Projektipäällikkö | 144h |
| 5 | 1.1.1.2 | Projektiorganisaatio |  | 18d? | 2010-01-01 | 2010-01-26 |  | 607d | 0d | finish no earlier than 2010-01-26 | Projektipäällikkö | 144h |
| 6 | 1.1.1.3 | Tavoitteet |  | 18d? | 2010-01-01 | 2010-01-26 |  | 607d | 0d | finish no earlier than 2010-01-26 | Projektipäällikkö | 144h |
| 7 | 1.1.1.4 | Resurssit |  | 18d? | 2010-01-01 | 2010-01-26 |  | 607d | 0d | finish no earlier than 2010-01-26 | Projektipäällikkö | 144h |
| 8 | 1.1.1.5 | Tarkistus |  | 1d? | 2010-01-27 | 2010-01-27 | 4, 5, 6, 7 | 607d | 3d | start no earlier than 2010-01-27 | Tiedonhallinta- ja järjestelmäpalvelut | 8h |
| 9 | 1.1.1.6 | Kommentointi |  | 1d? | 2010-02-02 | 2010-02-02 | 8 | 604d | 1d | start no earlier than 2010-02-02 | Koordinaatioryhmä | 8h |
| 10 | 1.1.1.7 | Hyväksyntä | milestone | 1d? | 2010-02-12 | 2010-02-12 | 9 | 597d |  | finish no earlier than 2010-02-12 | Ohjausryhmä | 8h |
| 11 | 1.1.2 | **Proof on concept ja teknologiavalinta** |  | 29d? | 2010-01-06 | 2010-02-15 |  | 596d |  |  |  | 504h |
| 12 | 1.1.2.1 | Testattavien tuotteiden valinta |  | 3d? | 2010-01-06 | 2010-01-08 |  | 622d |  | finish no earlier than 2010-01-08 | Muut asiantuntijat; Tiedonhallinta- ja järjestelmäpalvelut | 48h |
| 13 | 1.1.2.2 | Ympäristön asennus |  | 1d? | 2010-01-12 | 2010-01-12 |  | 603d | 0d | start no earlier than 2010-01-12 | Muut asiantuntijat; Eduix | 16h |
| 14 | 1.1.2.3 | Modulisuunnittelu |  | 8d? | 2010-01-13 | 2010-01-22 | 13 | 603d | 0d | start no earlier than 2010-01-13 | Eduix | 64h |
| 15 | 1.1.2.4 | Versiohallinnan pystytys |  | 8d? | 2010-01-13 | 2010-01-22 |  | 603d | 0d | finish no earlier than 2010-01-22 | Eduix | 64h |
| 16 | 1.1.2.5 | Skeemamäärittely |  | 8d? | 2010-01-13 | 2010-01-22 |  | 603d | 0d | finish no earlier than 2010-01-22 | Eduix; Muut asiantuntijat | 128h |
| 17 | 1.1.2.6 | Modulisuunnitelman läpikäynti |  | 1d? | 2010-01-25 | 2010-01-25 | 14, 15, 16 | 603d | 0d | start no earlier than 2010-01-25 | Eduix; Muut asiantuntijat | 16h |
| 18 | 1.1.2.7 | Toteutusvaihe |  | 7d? | 2010-01-26 | 2010-02-03 | 17 | 603d | 7d | start no earlier than 2010-01-26 | Eduix; Muut asiantuntijat | 112h |
| 19 | 1.1.2.8 | Loppukatselmointi | milestone | 1d? | 2010-02-15 | 2010-02-15 | 18 | 596d |  | start no earlier than 2010-02-15 | Tiedonhallinta- ja järjestelmäpalvelut | 8h |
| 20 | 1.1.2.9 | POC Raportti |  | 6d? | 2010-02-08 | 2010-02-15 |  | 596d |  | start no earlier than 2010-02-08 | Ekholm | 48h |
| 21 | 1.1.3 | **Konseptisuunnittelu** |  | 35d? | 2010-01-25 | 2010-03-12 |  | 577d |  |  |  | 280h |
| 22 | 1.1.3.1 | Määrittely |  | 5d? | 2010-01-25 | 2010-01-29 |  | 607d |  | finish no earlier than 2010-01-29 | Muut asiantuntijat | 40h |
| 23 | 1.1.3.2 | Suunnittelu |  | 5d? | 2010-02-01 | 2010-02-05 |  | 602d |  | start no earlier than 2010-02-01 | Muut asiantuntijat | 40h |
| 24 | 1.1.3.3 | Toteutus |  | 25d? | 2010-02-08 | 2010-03-12 |  | 577d |  | start no earlier than 2010-02-08 | Muut asiantuntijat | 200h |

| ID | WBS | Task | Duration | Start | Finish | Predecessors | Total slack | Free slack | Constraint | Resources | Work |
| --- | --- | --- | --- | --- | --- | --- | --- | --- | --- | --- | --- |
| 25 | 1.1.4 | **Sopimus** | 30d? | 2010-02-08 | 2010-03-19 |  | 572d |  |  |  | 400h |
| 26 | 1.1.4.1 | Tarjouspyyntö | 10d? | 2010-02-08 | 2010-02-19 |  | 572d | 0d | finish no earlier than 2010-02-19 | Projektipäällikkö; Muut asiantuntijat | 160h |
| 27 | 1.1.4.2 | Tarjouksen käsittely | 10d? | 2010-02-22 | 2010-03-05 | 26 | 572d | 0d | finish no earlier than 2010-03-05 | Tiedonhallinta- ja järjestelmäpalvelut; Tietohallintojohtaja | 160h |
| 28 | 1.1.4.3 | Hyväksyntä | 5d? | 2010-03-08 | 2010-03-12 | 27 | 572d | 0d | finish no earlier than 2010-02-19 | Ohjausryhmä | 40h |
| 29 | 1.1.4.4 | Sopimus | 5d? | 2010-03-15 | 2010-03-19 | 28 | 572d |  | finish no earlier than 2010-02-26 | Rehtori | 40h |
| 30 | 1.1.5 | **Määrittely & suunnittelu (alustava)** | 131d? | 2010-04-01 | 2010-09-30 |  | 433d |  |  |  | 5752h |
| 31 | 1.1.5.1 | Vaatimusmäärittely | 77d? | 2010-04-01 | 2010-07-16 |  | 487d |  | start no earlier than 2010-04-01 | Asiantuntijatyöryhmät | 616h |
| 32 | 1.1.5.2 | Palvelukartoitus | 77d? | 2010-04-01 | 2010-07-16 |  | 487d |  | finish no earlier than 2010-07-16 | Asiantuntijatyöryhmät; Projektiryhmä | 1232h |
| 33 | 1.1.5.3 | Tietojen määrittely | 55d? | 2010-05-03 | 2010-07-16 |  | 487d |  | finish no earlier than 2010-07-16 | Asiantuntijatyöryhmät; Projektiryhmä | 880h |
| 34 | 1.1.5.4 | Skeemojen määrittely | 54d? | 2010-07-19 | 2010-09-30 |  | 433d |  | start no earlier than 2010-07-19 | Projektiryhmä; Eduix; Muut asiantuntijat | 1296h |
| 35 | 1.1.5.5 | Tietomallit | 54d? | 2010-07-19 | 2010-09-30 |  | 433d |  | start no earlier than 2010-07-19 | Eduix; Muut asiantuntijat; Projektiryhmä | 1296h |
| 36 | 1.1.5.6 | Tietokannan suunnittelu | 54d? | 2010-07-19 | 2010-09-30 |  | 433d |  | start no earlier than 2010-07-19 | Eduix | 432h |
| 37 | 1.2 | **2. Vaihe** | 514d? | 2010-02-01 | 2012-01-23 |  | 93d |  |  |  | 12864h |
| 38 | 1.2.1 | **Testi- ja tuotanto(pilotti)palvelimen asennus** | 174d? | 2010-02-01 | 2010-09-30 |  | 433d |  |  |  | 2416h |
| 39 | 1.2.1.1 | Testipalvelimen asennus | 20d? | 2010-02-01 | 2010-02-26 |  | 587d |  | finish no earlier than 2010-02-26 | Muut asiantuntijat; Eduix | 320h |
| 40 | 1.2.1.2 | Tuotanto/pilotointi palvelimen asennus | 131d? | 2010-04-01 | 2010-09-30 |  | 433d |  | start no earlier than 2010-04-01 | Muut asiantuntijat; Eduix | 2096h |
| 41 | 1.2.2 | **Palveluiden toteutus** | 494d? | 2010-03-01 | 2012-01-23 |  | 93d |  |  |  | 10448h |
| 42 | 1.2.2.1 | **Opiskelijan tietopalvelut (suunnittelijan työpöytä)** | 131d? | 2010-04-01 | 2010-09-30 |  | 433d |  |  |  | 2640h |
| 43 | 1.2.2.1.1 | **OPS editori järjestelmäkokonaisuus palvelupohjaiseksi** | 131d? | 2010-04-01 | 2010-09-30 |  | 433d |  |  | Eduix | 2640h |
| 44 | 1.2.2.1.1.1 | Määrittely | 23d? | 2010-04-01 | 2010-05-03 |  | 541d |  | start no earlier than 2010-04-01 | Eduix; Projektiryhmä | 368h |
| 45 | 1.2.2.1.1.2 | Suunnittelu | 22d? | 2010-05-03 | 2010-06-01 |  | 520d |  | start no earlier than 2010-05-03 | Eduix | 176h |
| 46 | 1.2.2.1.1.3 | Toteutus | 43d? | 2010-06-02 | 2010-07-30 |  | 477d |  | start no earlier than 2010-06-02 | Eduix koodaajat | 344h |
| 47 | 1.2.2.1.1.4 | Testaus | 22d? | 2010-08-02 | 2010-08-31 |  | 455d |  | finish no earlier than 2010-08-31 | Projektiryhmä; Asiantuntijatyöryhmät; Eduix | 528h |
| 48 | 1.2.2.1.1.5 | Pilotointi | 22d? | 2010-09-01 | 2010-09-30 |  | 433d |  | finish no earlier than 2010-09-30 | Asiantuntijatyöryhmät | 176h |

| ID | WBS | Task | Duration | Start | Finish | Total slack | Constraint | Resources | Work |
| --- | --- | --- | --- | --- | --- | --- | --- | --- | --- |
| 49 | 1.2.2.2 | **Opetuksen järjestäjän palvelut (suunnittelijan työpöytä)** | 392d? | 2010-03-01 | 2011-08-31 | 195d |  |  | 3808h |
| 50 | 1.2.2.2.1 | **Vuosisuunnittelu** | 279d? | 2010-03-01 | 2011-03-25 | 308d |  |  | 2432h |
| 51 | 1.2.2.2.1.1 | **Toteutusten luominen** | 279d? | 2010-03-01 | 2011-03-25 | 308d |  |  | 608h |
| 52 | 1.2.2.2.1.1.1 | Määrittely | 80d? | 2010-03-01 | 2010-06-18 | 509d | finish no earlier than 2010-06-18 |  |  |
| 53 | 1.2.2.2.1.1.2 | Suunnittelu | 52d? | 2010-06-21 | 2010-08-31 | 457d | finish no earlier than 2010-08-31 |  |  |
| 54 | 1.2.2.2.1.1.3 | Demo | 22d? | 2010-09-01 | 2010-09-30 | 435d | start no earlier than 2010-09-01 |  |  |
| 55 | 1.2.2.2.1.1.4 | Hyväksyntä | 11d? | 2010-10-01 | 2010-10-15 | 424d | start no earlier than 2010-10-01 |  |  |
| 56 | 1.2.2.2.1.1.5 | Toteutus | 76d? | 2010-10-15 | 2011-01-31 | 347d | finish no earlier than 2011-01-31 | Eduix koodaajat | 608h |
| 57 | 1.2.2.2.1.1.6 | Testaus | 9d? | 2011-02-01 | 2011-02-11 | 339d | finish no earlier than 2011-02-11 |  |  |
| 58 | 1.2.2.2.1.1.7 | Pilotointi | 30d? | 2011-02-14 | 2011-03-25 | 309d | finish no earlier than 2011-03-25 |  |  |
| 59 | 1.2.2.2.1.2 | **Resurssit ja varaukset** | 279d? | 2010-03-01 | 2011-03-25 | 308d |  |  | 608h |
| 60 | 1.2.2.2.1.2.1 | Määrittely | 80d? | 2010-03-01 | 2010-06-18 | 509d | finish no earlier than 2010-06-18 |  |  |
| 61 | 1.2.2.2.1.2.2 | Suunnittelu | 52d? | 2010-06-21 | 2010-08-31 | 457d | start no earlier than 2010-06-21 |  |  |
| 62 | 1.2.2.2.1.2.3 | Demo | 22d? | 2010-09-01 | 2010-09-30 | 435d | start no earlier than 2010-09-01 |  |  |
| 63 | 1.2.2.2.1.2.4 | Hyväksyntä | 11d? | 2010-10-01 | 2010-10-15 | 424d | start no earlier than 2010-10-01 |  |  |
| 64 | 1.2.2.2.1.2.5 | Toteutus | 76d? | 2010-10-18 | 2011-02-01 | 346d | start no earlier than 2010-10-18 | Eduix koodaajat | 608h |
| 65 | 1.2.2.2.1.2.6 | Testaus | 9d? | 2011-02-01 | 2011-02-11 | 339d | start no earlier than 2011-02-01 |  |  |
| 66 | 1.2.2.2.1.2.7 | Pilotointi | 30d? | 2011-02-14 | 2011-03-25 | 309d | start no earlier than 2011-02-14 |  |  |
| 67 | 1.2.2.2.1.3 | **Työaikasuunnittelu** | 279d? | 2010-03-01 | 2011-03-25 | 308d |  |  | 608h |
| 68 | 1.2.2.2.1.3.1 | Määrittely | 80d? | 2010-03-01 | 2010-06-18 | 509d | start no earlier than 2010-03-01 |  |  |
| 69 | 1.2.2.2.1.3.2 | Suunnittelu | 52d? | 2010-06-21 | 2010-08-31 | 457d | start no earlier than 2010-06-21 |  |  |
| 70 | 1.2.2.2.1.3.3 | Demo | 22d? | 2010-09-01 | 2010-09-30 | 435d | start no earlier than 2010-09-01 |  |  |
| 71 | 1.2.2.2.1.3.4 | Hyväksyntä | 11d? | 2010-10-01 | 2010-10-15 | 424d | start no earlier than 2010-10-01 |  |  |
| 72 | 1.2.2.2.1.3.5 | Toteutus | 76d? | 2010-10-18 | 2011-02-01 | 346d | start no earlier than 2010-10-18 | Eduix koodaajat | 608h |
| 73 | 1.2.2.2.1.3.6 | Testaus | 9d? | 2011-02-01 | 2011-02-11 | 339d | start no earlier than 2011-02-01 |  |  |
| 74 | 1.2.2.2.1.3.7 | Pilotointi | 30d? | 2011-02-14 | 2011-03-25 | 309d | start no earlier than 2011-02-14 |  |  |

| ID | WBS | Task | Duration | Start | Finish | Total slack | Constraint | Resources | Work |
| --- | --- | --- | --- | --- | --- | --- | --- | --- | --- |
| 75 | 1.2.2.2.1.4 | **Seuranta-, raportointi ja julkaisupalvelut** | 279d? | 2010-03-01 | 2011-03-25 | 308d |  |  | 608h |
| 76 | 1.2.2.2.1.4.1 | Määrittely | 80d? | 2010-03-01 | 2010-06-18 | 509d | start no earlier than 2010-03-01 |  |  |
| 77 | 1.2.2.2.1.4.2 | Suunnittelu | 52d? | 2010-06-21 | 2010-08-31 | 457d | start no earlier than 2010-06-21 |  |  |
| 78 | 1.2.2.2.1.4.3 | Demo | 22d? | 2010-09-01 | 2010-09-30 | 435d | start no earlier than 2010-09-01 |  |  |
| 79 | 1.2.2.2.1.4.4 | Hyväksyntä | 11d? | 2010-10-01 | 2010-10-15 | 424d | start no earlier than 2010-10-01 |  |  |
| 80 | 1.2.2.2.1.4.5 | Toteutus | 76d? | 2010-10-18 | 2011-02-01 | 346d | start no earlier than 2010-10-18 | Eduix koodaajat | 608h |
| 81 | 1.2.2.2.1.4.6 | Testaus | 9d? | 2011-02-01 | 2011-02-11 | 339d | start no earlier than 2011-02-01 |  |  |
| 82 | 1.2.2.2.1.4.7 | Pilotointi | 30d? | 2011-02-14 | 2011-03-25 | 309d | start no earlier than 2011-02-14 |  |  |
| 83 | 1.2.2.2.2 | **Lukujärjestyssuunnittelu** | 369d? | 2010-04-01 | 2011-08-31 | 195d |  |  | 1376h |
| 84 | 1.2.2.2.2.1 | **Ryhmän, tilojen, opettajien ja opiskelijan lukujärjestyssuunnittelu** | 369d? | 2010-04-01 | 2011-08-31 | 195d |  |  | 688h |
| 85 | 1.2.2.2.2.1.1 | Määrittely | 162d? | 2010-04-01 | 2010-11-12 | 404d | finish no earlier than 2010-11-12 |  |  |
| 86 | 1.2.2.2.2.1.2 | Suunnittelu | 35d? | 2010-11-12 | 2010-12-31 | 368d | finish no earlier than 2010-12-31 |  |  |
| 87 | 1.2.2.2.2.1.3 | Demo | 10d? | 2011-01-03 | 2011-01-14 | 359d | finish no earlier than 2011-01-14 |  |  |
| 88 | 1.2.2.2.2.1.4 | Hyväksyntä | 11d? | 2011-01-17 | 2011-01-31 | 348d | finish no earlier than 2011-01-31 |  |  |
| 89 | 1.2.2.2.2.1.5 | Toteutus | 86d? | 2011-02-01 | 2011-05-31 | 261d | finish no earlier than 2011-05-31 | Eduix koodaajat | 688h |
| 90 | 1.2.2.2.2.1.6 | Testaus | 13d? | 2011-06-01 | 2011-06-17 | 249d | finish no earlier than 2011-06-17 |  |  |
| 91 | 1.2.2.2.2.1.7 | Pilotointi | 53d? | 2011-06-20 | 2011-08-31 | 196d | start no earlier than 2011-06-20 |  |  |
| 92 | 1.2.2.2.2.2 | **Seuranta-, raportointi ja julkaisupalvelut** | 369d? | 2010-04-01 | 2011-08-31 | 195d |  |  | 688h |
| 93 | 1.2.2.2.2.2.1 | Määrittely | 162d? | 2010-04-01 | 2010-11-12 | 404d | start no earlier than 2010-04-01 |  |  |
| 94 | 1.2.2.2.2.2.2 | Suunnittelu | 35d? | 2010-11-15 | 2011-01-03 | 367d | start no earlier than 2010-11-15 |  |  |
| 95 | 1.2.2.2.2.2.3 | Demo | 10d? | 2011-01-03 | 2011-01-14 | 359d | start no earlier than 2011-01-03 |  |  |
| 96 | 1.2.2.2.2.2.4 | Hyväksyntä | 11d? | 2011-01-17 | 2011-01-31 | 348d | start no earlier than 2011-01-17 |  |  |
| 97 | 1.2.2.2.2.2.5 | Toteutus | 86d? | 2011-02-01 | 2011-05-31 | 261d | finish no earlier than 2011-05-31 | Eduix koodaajat | 688h |
| 98 | 1.2.2.2.2.2.6 | Testaus | 13d? | 2011-06-01 | 2011-06-17 | 249d | start no earlier than 2011-06-01 |  |  |
| 99 | 1.2.2.2.2.2.7 | Pilotointi | 53d? | 2011-06-20 | 2011-08-31 | 196d | start no earlier than 2011-06-20 |  |  |

| ID | WBS | Task | Duration | Start | Finish | Total slack | Constraint | Resources | Work |
| --- | --- | --- | --- | --- | --- | --- | --- | --- | --- |
| 100 | 1.2.2.3 | **Opettajan palvelut (opettajan työpöytä)** | 471d? | 2010-04-01 | 2012-01-23 | 93d |  |  | 4000h |
| 101 | 1.2.2.3.1 | **Työaikasuunnitelmien kommentointi** | 470d? | 2010-04-01 | 2012-01-20 | 94d |  |  | 800h |
| 102 | 1.2.2.3.1.1 | Määrittely | 216d? | 2010-04-01 | 2011-01-28 | 348d | start no earlier than 2010-04-01 |  |  |
| 103 | 1.2.2.3.1.2 | Suunnittelu | 59d? | 2011-02-01 | 2011-04-22 | 289d | finish no earlier than 2011-04-22 |  |  |
| 104 | 1.2.2.3.1.3 | Demo | 20d? | 2011-04-25 | 2011-05-20 | 269d | finish no earlier than 2011-05-20 |  |  |
| 105 | 1.2.2.3.1.4 | Hyväksyntä | 15d? | 2011-05-23 | 2011-06-10 | 254d | start no earlier than 2011-05-23 |  |  |
| 106 | 1.2.2.3.1.5 | Toteutus | 100d? | 2011-06-13 | 2011-10-28 | 153d | finish no earlier than 2011-10-28 | Eduix koodaajat | 800h |
| 107 | 1.2.2.3.1.6 | Testaus | 14d? | 2011-11-01 | 2011-11-18 | 139d | finish no earlier than 2011-11-18 |  |  |
| 108 | 1.2.2.3.1.7 | Pilotointi | 45d? | 2011-11-18 | 2012-01-20 | 94d | finish no earlier than 2012-01-20 |  |  |
| 109 | 1.2.2.3.2 | **Toteutussuunnittelu + OJP palvelupohjaiseksi** | 471d? | 2010-04-01 | 2012-01-23 | 93d |  |  | 800h |
| 110 | 1.2.2.3.2.1 | Määrittely | 217d? | 2010-04-01 | 2011-01-31 | 347d | start no earlier than 2010-04-01 |  |  |
| 111 | 1.2.2.3.2.2 | Suunnittelu | 59d? | 2011-02-01 | 2011-04-22 | 289d | start no earlier than 2011-02-01 |  |  |
| 112 | 1.2.2.3.2.3 | Demo | 20d? | 2011-04-25 | 2011-05-20 | 269d | start no earlier than 2011-04-25 |  |  |
| 113 | 1.2.2.3.2.4 | Hyväksyntä | 15d? | 2011-05-23 | 2011-06-10 | 254d | start no earlier than 2011-05-23 |  |  |
| 114 | 1.2.2.3.2.5 | Toteutus | 100d? | 2011-06-13 | 2011-10-28 | 153d | start no earlier than 2011-06-13 | Eduix koodaajat | 800h |
| 115 | 1.2.2.3.2.6 | Testaus | 14d? | 2011-11-01 | 2011-11-18 | 139d | start no earlier than 2011-11-01 |  |  |
| 116 | 1.2.2.3.2.7 | Pilotointi | 45d? | 2011-11-21 | 2012-01-23 | 93d | start no earlier than 2011-11-21 |  |  |
| 117 | 1.2.2.3.3 | **Opetustapahtumien muokkaus (opetuspäiväkirjat, opetustapahtuman peruuttaminen yms.)** | 471d? | 2010-04-01 | 2012-01-23 | 93d |  |  | 800h |
| 118 | 1.2.2.3.3.1 | Määrittely | 217d? | 2010-04-01 | 2011-01-31 | 347d | start no earlier than 2010-04-01 |  |  |
| 119 | 1.2.2.3.3.2 | Suunnittelu | 59d? | 2011-02-01 | 2011-04-22 | 289d | start no earlier than 2011-02-01 |  |  |
| 120 | 1.2.2.3.3.3 | Demo | 20d? | 2011-04-25 | 2011-05-20 | 269d | start no earlier than 2011-04-25 |  |  |
| 121 | 1.2.2.3.3.4 | Hyväksyntä | 15d? | 2011-05-23 | 2011-06-10 | 254d | start no earlier than 2011-05-23 |  |  |
| 122 | 1.2.2.3.3.5 | Toteutus | 100d? | 2011-06-13 | 2011-10-28 | 153d | start no earlier than 2011-06-13 | Eduix koodaajat | 800h |
| 123 | 1.2.2.3.3.6 | Testaus | 14d? | 2011-11-01 | 2011-11-18 | 139d | start no earlier than 2011-11-01 |  |  |
| 124 | 1.2.2.3.3.7 | Pilotointi | 45d? | 2011-11-21 | 2012-01-23 | 93d | start no earlier than 2011-11-21 |  |  |

| ID | WBS | Task | Duration | Start | Finish | Total slack | Constraint | Resources | Work |
| --- | --- | --- | --- | --- | --- | --- | --- | --- | --- |
| 125 | 1.2.2.3.4 | **Opiskelijan hyväksyminen toteutukselle ja arvosanojen antaminen** | 471d? | 2010-04-01 | 2012-01-23 | 93d |  |  | 800h |
| 126 | 1.2.2.3.4.1 | Määrittely | 217d? | 2010-04-01 | 2011-01-31 | 347d | start no earlier than 2010-04-01 |  |  |
| 127 | 1.2.2.3.4.2 | Suunnittelu | 59d? | 2011-02-01 | 2011-04-22 | 289d | start no earlier than 2011-02-01 |  |  |
| 128 | 1.2.2.3.4.3 | Demo | 20d? | 2011-04-25 | 2011-05-20 | 269d | start no earlier than 2011-04-25 |  |  |
| 129 | 1.2.2.3.4.4 | Hyväksyntä | 15d? | 2011-05-23 | 2011-06-10 | 254d | start no earlier than 2011-05-23 |  |  |
| 130 | 1.2.2.3.4.5 | Toteutus | 100d? | 2011-06-13 | 2011-10-28 | 153d | start no earlier than 2011-06-13 | Eduix koodaajat | 800h |
| 131 | 1.2.2.3.4.6 | Testaus | 14d? | 2011-11-01 | 2011-11-18 | 139d | start no earlier than 2011-11-01 |  |  |
| 132 | 1.2.2.3.4.7 | Pilotointi | 45d? | 2011-11-21 | 2012-01-23 | 93d | start no earlier than 2011-11-21 |  |  |
| 133 | 1.2.2.3.5 | **Seuranta-, raportointi ja julkaisupalvelut** | 471d? | 2010-04-01 | 2012-01-23 | 93d |  |  | 800h |
| 134 | 1.2.2.3.5.1 | Määrittely | 217d? | 2010-04-01 | 2011-01-31 | 347d | start no earlier than 2010-04-01 |  |  |
| 135 | 1.2.2.3.5.2 | Suunnittelu | 59d? | 2011-02-01 | 2011-04-22 | 289d | start no earlier than 2011-02-01 |  |  |
| 136 | 1.2.2.3.5.3 | Demo | 20d? | 2011-04-25 | 2011-05-20 | 269d | start no earlier than 2011-04-25 |  |  |
| 137 | 1.2.2.3.5.4 | Hyväksyntä | 15d? | 2011-05-23 | 2011-06-10 | 254d | start no earlier than 2011-05-23 |  |  |
| 138 | 1.2.2.3.5.5 | Toteutus | 100d? | 2011-06-13 | 2011-10-28 | 153d | start no earlier than 2011-06-13 | Eduix koodaajat | 800h |
| 139 | 1.2.2.3.5.6 | Testaus | 14d? | 2011-11-01 | 2011-11-18 | 139d | start no earlier than 2011-11-01 |  |  |
| 140 | 1.2.2.3.5.7 | Pilotointi | 45d? | 2011-11-21 | 2012-01-23 | 93d | start no earlier than 2011-11-21 |  |  |
| 141 | 1.3 | **3. Vaihe** | 219d? | 2011-07-29 | 2012-05-31 | 0d |  |  |  |
| 142 | 1.3.1 | Lopputestaus ja virheiden korjaus | 66d? | 2011-08-01 | 2011-10-31 | 153d | finish no earlier than 2011-10-31 |  |  |
| 143 | 1.3.2 | Koulutusohjelmien pilotointi | 110d? | 2011-07-29 | 2011-12-30 | 109d | finish no earlier than 2011-12-30 |  |  |
| 144 | 1.3.3 | Metropolia henkilökunnan koulutus | 174d? | 2011-09-30 | 2012-05-31 | 0d | finish no earlier than 2012-05-31 |  |  |
| 145 | 1.3.4 | Kaikkien palveluiden käyttöönotto | 131d? | 2011-11-30 | 2012-05-31 | 0d | finish no earlier than 2012-05-31 |  |  |
