# aikataulu_1_0

Schedule from MS Project, 2010-01-01 to 2012-05-31.
HKIAMK

## Calendars

- Standard: Mon-Fri 08:00-12:00, 13:00-17:00; Sat-Sun off. Exceptions (off unless hours are given): 2010-12-06, 2011-12-06.

## Resources

| Resource |
| --- |
| Ohjausryhmä |
| Eduix |
| Ekholm |
| Rannila |
| Asiantuntijatyöryhmät |
| Projektiryhmä |
| Asiantuntijatyöryhmät, Projektiryhmä |
| Muut asiantuntijat |
| Tiedonhallinta- ja järjestelmäpalvelut |
| Koordinaatioryhmä |
| Projektipäällikkö |
| Tietohallintojohtaja |
| Rehtori |
| Eduix koodaajat |
| Rehtorit |

## Schedule

| ID | WBS | Task | Type | Duration | Start | Finish | Predecessors | Total slack | Free slack | Constraint | Resources | Work |
| --- | --- | --- | --- | --- | --- | --- | --- | --- | --- | --- | --- | --- |
| 1 | 1 | **TOISU III** |  | 628d? | 2010-01-01 | 2012-05-31 |  | 0d |  |  |  | 25352h |
| 2 | 1.1 | **1. Vaihe** |  | 216d? | 2010-01-01 | 2010-10-29 |  | 412d |  |  |  | 11472h |
| 3 | 1.1.1 | **Projektisuunnitelma** |  | 70d? | 2010-01-01 | 2010-04-08 |  | 558d |  |  | Projektipäällikkö | 1176h |
| 4 | 1.1.1.1 | Aikataulu |  | 18d? | 2010-01-01 | 2010-01-26 |  | 607d | 0d | finish no earlier than 2010-01-26 | Projektipäällikkö | 144h |
| 5 | 1.1.1.2 | Projektiorganisaatio |  | 18d? | 2010-01-01 | 2010-01-26 |  | 607d | 0d | finish no earlier than 2010-01-26 | Projektipäällikkö | 144h |
| 6 | 1.1.1.3 | Tavoitteet |  | 18d? | 2010-01-01 | 2010-01-26 |  | 607d | 0d | finish no earlier than 2010-01-26 | Projektipäällikkö | 144h |
| 7 | 1.1.1.4 | Resurssit |  | 18d? | 2010-01-01 | 2010-01-26 |  | 607d | 0d | finish no earlier than 2010-01-26 | Projektipäällikkö | 144h |
| 8 | 1.1.1.5 | Tarkistus |  | 1d? | 2010-01-27 | 2010-01-27 | 4, 5, 6, 7 | 607d | 3d | start no earlier than 2010-01-27 | Tiedonhallinta- ja järjestelmäpalvelut | 8h |
| 9 | 1.1.1.6 | Kommentointi |  | 1d? | 2010-02-02 | 2010-02-02 | 8 | 604d | 1d | start no earlier than 2010-02-02 | Koordinaatioryhmä | 8h |
| 10 | 1.1.1.7 | Päätös projektin aloittamisesta |  | 1d? | 2010-03-24 | 2010-03-24 |  | 568d | 10d | start no earlier than 2010-03-24 | Rehtori | 8h |
| 11 | 1.1.1.8 | Konsortiosopimus |  | 1d? | 2010-03-31 | 2010-03-31 |  | 563d | 5d | start no earlier than 2010-03-31 | Rehtorit | 8h |
| 12 | 1.1.1.9 | Hyväksyntä | milestone | 1d? | 2010-04-08 | 2010-04-08 | 11, 9 | 558d |  | finish no earlier than 2010-04-08 | Ohjausryhmä | 8h |
| 13 | 1.1.2 | **Proof on concept ja teknologiavalinta** |  | 29d? | 2010-01-06 | 2010-02-15 |  | 596d |  |  |  | 504h |
| 14 | 1.1.2.1 | Testattavien tuotteiden valinta |  | 3d? | 2010-01-06 | 2010-01-08 |  | 622d |  | finish no earlier than 2010-01-08 | Muut asiantuntijat; Tiedonhallinta- ja järjestelmäpalvelut | 48h |
| 15 | 1.1.2.2 | Ympäristön asennus |  | 1d? | 2010-01-12 | 2010-01-12 |  | 603d | 0d | start no earlier than 2010-01-12 | Muut asiantuntijat; Eduix | 16h |
| 16 | 1.1.2.3 | Modulisuunnittelu |  | 8d? | 2010-01-13 | 2010-01-22 | 15 | 603d | 0d | start no earlier than 2010-01-13 | Eduix | 64h |
| 17 | 1.1.2.4 | Versiohallinnan pystytys |  | 8d? | 2010-01-13 | 2010-01-22 |  | 603d | 0d | finish no earlier than 2010-01-22 | Eduix | 64h |
| 18 | 1.1.2.5 | Skeemamäärittely |  | 8d? | 2010-01-13 | 2010-01-22 |  | 603d | 0d | finish no earlier than 2010-01-22 | Eduix; Muut asiantuntijat | 128h |
| 19 | 1.1.2.6 | Modulisuunnitelman läpikäynti |  | 1d? | 2010-01-25 | 2010-01-25 | 16, 17, 18 | 603d | 0d | start no earlier than 2010-01-25 | Eduix; Muut asiantuntijat | 16h |
| 20 | 1.1.2.7 | Toteutusvaihe |  | 7d? | 2010-01-26 | 2010-02-03 | 19 | 603d | 7d | start no earlier than 2010-01-26 | Eduix; Muut asiantuntijat | 112h |
| 21 | 1.1.2.8 | Loppukatselmointi | milestone | 1d? | 2010-02-15 | 2010-02-15 | 20 | 596d |  | start no earlier than 2010-02-15 | Tiedonhallinta- ja järjestelmäpalvelut | 8h |
| 22 | 1.1.2.9 | POC Raportti |  | 6d? | 2010-02-08 | 2010-02-15 |  | 596d |  | start no earlier than 2010-02-08 | Ekholm | 48h |
| 23 | 1.1.3 | **Konseptisuunnittelu** |  | 48d? | 2010-01-25 | 2010-03-31 |  | 564d |  |  |  | 384h |
| 24 | 1.1.3.1 | Määrittely |  | 5d? | 2010-01-25 | 2010-01-29 |  | 607d |  | finish no earlier than 2010-01-29 | Muut asiantuntijat | 40h |
| 25 | 1.1.3.2 | Suunnittelu |  | 5d? | 2010-02-01 | 2010-02-05 |  | 602d |  | start no earlier than 2010-02-01 | Muut asiantuntijat | 40h |
| 26 | 1.1.3.3 | Toteutus |  | 38d? | 2010-02-08 | 2010-03-31 |  | 564d |  | finish no earlier than 2010-03-31 | Muut asiantuntijat | 304h |

| ID | WBS | Task | Duration | Start | Finish | Predecessors | Total slack | Free slack | Constraint | Resources | Work |
| --- | --- | --- | --- | --- | --- | --- | --- | --- | --- | --- | --- |
| 27 | 1.1.4 | **Sopimus** | 25d? | 2010-04-12 | 2010-05-14 |  | 532d |  |  |  | 320h |
| 28 | 1.1.4.1 | Tarjouspyyntö | 5d? | 2010-04-12 | 2010-04-16 |  | 532d | 0d | finish no earlier than 2010-04-16 | Projektipäällikkö; Muut asiantuntijat | 80h |
| 29 | 1.1.4.2 | Tarjouksen käsittely | 10d? | 2010-04-19 | 2010-04-30 | 28 | 532d | 0d | finish no earlier than 2010-03-05 | Tiedonhallinta- ja järjestelmäpalvelut; Tietohallintojohtaja | 160h |
| 30 | 1.1.4.3 | Hyväksyntä | 5d? | 2010-05-03 | 2010-05-07 | 29 | 532d | 0d | finish no earlier than 2010-02-19 | Ohjausryhmä | 40h |
| 31 | 1.1.4.4 | Sopimus | 5d? | 2010-05-10 | 2010-05-14 | 30 | 532d |  | finish no earlier than 2010-02-26 | Rehtori | 40h |
| 32 | 1.1.5 | **Määrittely & suunnittelu (alustava)** | 152d? | 2010-04-01 | 2010-10-29 |  | 412d |  |  |  | 9088h |
| 33 | 1.1.5.1 | Vaatimusmäärittely | 131d? | 2010-04-01 | 2010-09-30 |  | 433d |  | start no earlier than 2010-04-01 | Asiantuntijatyöryhmät | 1048h |
| 34 | 1.1.5.2 | Palvelukartoitus | 131d? | 2010-04-01 | 2010-09-30 |  | 433d |  | finish no earlier than 2010-09-30 | Asiantuntijatyöryhmät; Projektiryhmä | 2096h |
| 35 | 1.1.5.3 | Tietojen määrittely | 109d? | 2010-05-03 | 2010-09-30 |  | 433d |  | finish no earlier than 2010-09-30 | Asiantuntijatyöryhmät; Projektiryhmä | 1744h |
| 36 | 1.1.5.4 | Skeemojen määrittely | 75d? | 2010-07-19 | 2010-10-29 |  | 412d |  | finish no earlier than 2010-10-29 | Projektiryhmä; Eduix; Muut asiantuntijat | 1800h |
| 37 | 1.1.5.5 | Tietomallit | 75d? | 2010-07-19 | 2010-10-29 |  | 412d |  | finish no earlier than 2010-10-29 | Eduix; Muut asiantuntijat; Projektiryhmä | 1800h |
| 38 | 1.1.5.6 | Tietokannan suunnittelu | 75d? | 2010-07-19 | 2010-10-29 |  | 412d |  | finish no earlier than 2010-10-29 | Eduix | 600h |
| 39 | 1.2 | **2. Vaihe** | 514d? | 2010-02-01 | 2012-01-23 |  | 93d |  |  |  | 13880h |
| 40 | 1.2.1 | **Testi- ja tuotanto(pilotti)palvelimen asennus** | 195d? | 2010-02-01 | 2010-10-29 |  | 412d |  |  |  | 2752h |
| 41 | 1.2.1.1 | Testipalvelimen asennus | 20d? | 2010-02-01 | 2010-02-26 |  | 587d |  | finish no earlier than 2010-02-26 | Muut asiantuntijat; Eduix | 320h |
| 42 | 1.2.1.2 | Tuotanto/pilotointi palvelimen asennus | 152d? | 2010-04-01 | 2010-10-29 |  | 412d |  | finish no earlier than 2010-10-29 | Muut asiantuntijat; Eduix | 2432h |
| 43 | 1.2.2 | **Palveluiden toteutus** | 471d? | 2010-04-01 | 2012-01-23 |  | 93d |  |  |  | 11128h |
| 44 | 1.2.2.1 | **Opiskelijan tietopalvelut (suunnittelijan työpöytä)** | 153d? | 2010-04-01 | 2010-11-01 |  | 411d |  |  |  | 3320h |
| 45 | 1.2.2.1.1 | **OPS editori järjestelmäkokonaisuus palvelupohjaiseksi** | 153d? | 2010-04-01 | 2010-11-01 |  | 411d |  |  | Eduix | 3320h |
| 46 | 1.2.2.1.1.1 | Määrittely | 43d? | 2010-04-01 | 2010-05-31 |  | 521d |  | finish no earlier than 2010-05-31 | Eduix; Projektiryhmä | 688h |
| 47 | 1.2.2.1.1.2 | Suunnittelu | 22d? | 2010-06-01 | 2010-06-30 |  | 499d |  | finish no earlier than 2010-06-30 | Eduix | 176h |
| 48 | 1.2.2.1.1.3 | Toteutus | 66d? | 2010-07-01 | 2010-09-30 |  | 433d |  | finish no earlier than 2010-09-30 | Eduix koodaajat | 528h |
| 49 | 1.2.2.1.1.4 | Testaus | 22d? | 2010-10-01 | 2010-11-01 |  | 411d |  | start no earlier than 2010-10-01 | Projektiryhmä; Asiantuntijatyöryhmät; Eduix | 528h |
| 50 | 1.2.2.1.1.5 | Pilotointi | 22d? | 2010-10-01 | 2010-11-01 |  | 411d |  | start no earlier than 2010-10-01 | Asiantuntijatyöryhmät | 176h |

| ID | WBS | Task | Duration | Start | Finish | Total slack | Constraint | Resources | Work |
| --- | --- | --- | --- | --- | --- | --- | --- | --- | --- |
| 51 | 1.2.2.2 | **Opetuksen järjestäjän palvelut (suunnittelijan työpöytä)** | 369d? | 2010-04-01 | 2011-08-31 | 195d |  |  | 3808h |
| 52 | 1.2.2.2.1 | **Vuosisuunnittelu** | 256d? | 2010-04-01 | 2011-03-25 | 308d |  |  | 2432h |
| 53 | 1.2.2.2.1.1 | **Toteutusten luominen** | 256d? | 2010-04-01 | 2011-03-25 | 308d |  |  | 608h |
| 54 | 1.2.2.2.1.1.1 | Määrittely | 57d? | 2010-04-01 | 2010-06-18 | 507d | start no earlier than 2010-04-01 |  |  |
| 55 | 1.2.2.2.1.1.2 | Suunnittelu | 52d? | 2010-06-21 | 2010-08-31 | 455d | finish no earlier than 2010-08-31 |  |  |
| 56 | 1.2.2.2.1.1.3 | Demo | 22d? | 2010-09-01 | 2010-09-30 | 433d | start no earlier than 2010-09-01 |  |  |
| 57 | 1.2.2.2.1.1.4 | Hyväksyntä | 11d? | 2010-10-01 | 2010-10-15 | 422d | start no earlier than 2010-10-01 |  |  |
| 58 | 1.2.2.2.1.1.5 | Toteutus | 76d? | 2010-10-15 | 2011-01-31 | 347d | finish no earlier than 2011-01-31 | Eduix koodaajat | 608h |
| 59 | 1.2.2.2.1.1.6 | Testaus | 9d? | 2011-02-01 | 2011-02-11 | 338d | finish no earlier than 2011-02-11 |  |  |
| 60 | 1.2.2.2.1.1.7 | Pilotointi | 30d? | 2011-02-14 | 2011-03-25 | 308d | finish no earlier than 2011-03-25 |  |  |
| 61 | 1.2.2.2.1.2 | **Resurssit ja varaukset** | 256d? | 2010-04-01 | 2011-03-25 | 308d |  |  | 608h |
| 62 | 1.2.2.2.1.2.1 | Määrittely | 57d? | 2010-04-01 | 2010-06-18 | 507d | start no earlier than 2010-04-01 |  |  |
| 63 | 1.2.2.2.1.2.2 | Suunnittelu | 52d? | 2010-06-21 | 2010-08-31 | 455d | start no earlier than 2010-06-21 |  |  |
| 64 | 1.2.2.2.1.2.3 | Demo | 22d? | 2010-09-01 | 2010-09-30 | 433d | start no earlier than 2010-09-01 |  |  |
| 65 | 1.2.2.2.1.2.4 | Hyväksyntä | 11d? | 2010-10-01 | 2010-10-15 | 422d | start no earlier than 2010-10-01 |  |  |
| 66 | 1.2.2.2.1.2.5 | Toteutus | 76d? | 2010-10-18 | 2011-02-01 | 346d | start no earlier than 2010-10-18 | Eduix koodaajat | 608h |
| 67 | 1.2.2.2.1.2.6 | Testaus | 9d? | 2011-02-01 | 2011-02-11 | 338d | start no earlier than 2011-02-01 |  |  |
| 68 | 1.2.2.2.1.2.7 | Pilotointi | 30d? | 2011-02-14 | 2011-03-25 | 308d | start no earlier than 2011-02-14 |  |  |
| 69 | 1.2.2.2.1.3 | **Työaikasuunnittelu** | 256d? | 2010-04-01 | 2011-03-25 | 308d |  |  | 608h |
| 70 | 1.2.2.2.1.3.1 | Määrittely | 57d? | 2010-04-01 | 2010-06-18 | 507d | start no earlier than 2010-04-01 |  |  |
| 71 | 1.2.2.2.1.3.2 | Suunnittelu | 52d? | 2010-06-21 | 2010-08-31 | 455d | start no earlier than 2010-06-21 |  |  |
| 72 | 1.2.2.2.1.3.3 | Demo | 22d? | 2010-09-01 | 2010-09-30 | 433d | start no earlier than 2010-09-01 |  |  |
| 73 | 1.2.2.2.1.3.4 | Hyväksyntä | 11d? | 2010-10-01 | 2010-10-15 | 422d | start no earlier than 2010-10-01 |  |  |
| 74 | 1.2.2.2.1.3.5 | Toteutus | 76d? | 2010-10-18 | 2011-02-01 | 346d | start no earlier than 2010-10-18 | Eduix koodaajat | 608h |
| 75 | 1.2.2.2.1.3.6 | Testaus | 9d? | 2011-02-01 | 2011-02-11 | 338d | start no earlier than 2011-02-01 |  |  |
| 76 | 1.2.2.2.1.3.7 | Pilotointi | 30d? | 2011-02-14 | 2011-03-25 | 308d | start no earlier than 2011-02-14 |  |  |

| ID | WBS | Task | Duration | Start | Finish | Total slack | Constraint | Resources | Work |
| --- | --- | --- | --- | --- | --- | --- | --- | --- | --- |
| 77 | 1.2.2.2.1.4 | **Seuranta-, raportointi ja julkaisupalvelut** | 256d? | 2010-04-01 | 2011-03-25 | 308d |  |  | 608h |
| 78 | 1.2.2.2.1.4.1 | Määrittely | 57d? | 2010-04-01 | 2010-06-18 | 507d | start no earlier than 2010-04-01 |  |  |
| 79 | 1.2.2.2.1.4.2 | Suunnittelu | 52d? | 2010-06-21 | 2010-08-31 | 455d | start no earlier than 2010-06-21 |  |  |
| 80 | 1.2.2.2.1.4.3 | Demo | 22d? | 2010-09-01 | 2010-09-30 | 433d | start no earlier than 2010-09-01 |  |  |
| 81 | 1.2.2.2.1.4.4 | Hyväksyntä | 11d? | 2010-10-01 | 2010-10-15 | 422d | start no earlier than 2010-10-01 |  |  |
| 82 | 1.2.2.2.1.4.5 | Toteutus | 76d? | 2010-10-18 | 2011-02-01 | 346d | start no earlier than 2010-10-18 | Eduix koodaajat | 608h |
| 83 | 1.2.2.2.1.4.6 | Testaus | 9d? | 2011-02-01 | 2011-02-11 | 338d | start no earlier than 2011-02-01 |  |  |
| 84 | 1.2.2.2.1.4.7 | Pilotointi | 30d? | 2011-02-14 | 2011-03-25 | 308d | start no earlier than 2011-02-14 |  |  |
| 85 | 1.2.2.2.2 | **Lukujärjestyssuunnittelu** | 369d? | 2010-04-01 | 2011-08-31 | 195d |  |  | 1376h |
| 86 | 1.2.2.2.2.1 | **Ryhmän, tilojen, opettajien ja opiskelijan lukujärjestyssuunnittelu** | 369d? | 2010-04-01 | 2011-08-31 | 195d |  |  | 688h |
| 87 | 1.2.2.2.2.1.1 | Määrittely | 162d? | 2010-04-01 | 2010-11-12 | 402d | start no earlier than 2010-04-01 |  |  |
| 88 | 1.2.2.2.2.1.2 | Suunnittelu | 35d? | 2010-11-12 | 2010-12-31 | 368d | finish no earlier than 2010-12-31 |  |  |
| 89 | 1.2.2.2.2.1.3 | Demo | 10d? | 2011-01-03 | 2011-01-14 | 358d | finish no earlier than 2011-01-14 |  |  |
| 90 | 1.2.2.2.2.1.4 | Hyväksyntä | 11d? | 2011-01-17 | 2011-01-31 | 347d | finish no earlier than 2011-01-31 |  |  |
| 91 | 1.2.2.2.2.1.5 | Toteutus | 86d? | 2011-02-01 | 2011-05-31 | 261d | finish no earlier than 2011-05-31 | Eduix koodaajat | 688h |
| 92 | 1.2.2.2.2.1.6 | Testaus | 13d? | 2011-06-01 | 2011-06-17 | 248d | finish no earlier than 2011-06-17 |  |  |
| 93 | 1.2.2.2.2.1.7 | Pilotointi | 53d? | 2011-06-20 | 2011-08-31 | 195d | start no earlier than 2011-06-20 |  |  |
| 94 | 1.2.2.2.2.2 | **Seuranta-, raportointi ja julkaisupalvelut** | 369d? | 2010-04-01 | 2011-08-31 | 195d |  |  | 688h |
| 95 | 1.2.2.2.2.2.1 | Määrittely | 162d? | 2010-04-01 | 2010-11-12 | 402d | start no earlier than 2010-04-01 |  |  |
| 96 | 1.2.2.2.2.2.2 | Suunnittelu | 35d? | 2010-11-15 | 2011-01-03 | 367d | start no earlier than 2010-11-15 |  |  |
| 97 | 1.2.2.2.2.2.3 | Demo | 10d? | 2011-01-03 | 2011-01-14 | 358d | start no earlier than 2011-01-03 |  |  |
| 98 | 1.2.2.2.2.2.4 | Hyväksyntä | 11d? | 2011-01-17 | 2011-01-31 | 347d | start no earlier than 2011-01-17 |  |  |
| 99 | 1.2.2.2.2.2.5 | Toteutus | 86d? | 2011-02-01 | 2011-05-31 | 261d | finish no earlier than 2011-05-31 | Eduix koodaajat | 688h |
| 100 | 1.2.2.2.2.2.6 | Testaus | 13d? | 2011-06-01 | 2011-06-17 | 248d | start no earlier than 2011-06-01 |  |  |
| 101 | 1.2.2.2.2.2.7 | Pilotointi | 53d? | 2011-06-20 | 2011-08-31 | 195d | start no earlier than 2011-06-20 |  |  |

| ID | WBS | Task | Duration | Start | Finish | Total slack | Constraint | Resources | Work |
| --- | --- | --- | --- | --- | --- | --- | --- | --- | --- |
| 102 | 1.2.2.3 | **Opettajan palvelut (opettajan työpöytä)** | 471d? | 2010-04-01 | 2012-01-23 | 93d |  |  | 4000h |
| 103 | 1.2.2.3.1 | **Työaikasuunnitelmien kommentointi** | 470d? | 2010-04-01 | 2012-01-20 | 94d |  |  | 800h |
| 104 | 1.2.2.3.1.1 | Määrittely | 216d? | 2010-04-01 | 2011-01-28 | 348d | start no earlier than 2010-04-01 |  |  |
| 105 | 1.2.2.3.1.2 | Suunnittelu | 59d? | 2011-02-01 | 2011-04-22 | 288d | finish no earlier than 2011-04-22 |  |  |
| 106 | 1.2.2.3.1.3 | Demo | 20d? | 2011-04-25 | 2011-05-20 | 268d | finish no earlier than 2011-05-20 |  |  |
| 107 | 1.2.2.3.1.4 | Hyväksyntä | 15d? | 2011-05-23 | 2011-06-10 | 253d | start no earlier than 2011-05-23 |  |  |
| 108 | 1.2.2.3.1.5 | Toteutus | 100d? | 2011-06-13 | 2011-10-28 | 153d | finish no earlier than 2011-10-28 | Eduix koodaajat | 800h |
| 109 | 1.2.2.3.1.6 | Testaus | 14d? | 2011-11-01 | 2011-11-18 | 138d | finish no earlier than 2011-11-18 |  |  |
| 110 | 1.2.2.3.1.7 | Pilotointi | 45d? | 2011-11-18 | 2012-01-20 | 94d | finish no earlier than 2012-01-20 |  |  |
| 111 | 1.2.2.3.2 | **Toteutussuunnittelu + OJP palvelupohjaiseksi** | 471d? | 2010-04-01 | 2012-01-23 | 93d |  |  | 800h |
| 112 | 1.2.2.3.2.1 | Määrittely | 217d? | 2010-04-01 | 2011-01-31 | 347d | start no earlier than 2010-04-01 |  |  |
| 113 | 1.2.2.3.2.2 | Suunnittelu | 59d? | 2011-02-01 | 2011-04-22 | 288d | start no earlier than 2011-02-01 |  |  |
| 114 | 1.2.2.3.2.3 | Demo | 20d? | 2011-04-25 | 2011-05-20 | 268d | start no earlier than 2011-04-25 |  |  |
| 115 | 1.2.2.3.2.4 | Hyväksyntä | 15d? | 2011-05-23 | 2011-06-10 | 253d | start no earlier than 2011-05-23 |  |  |
| 116 | 1.2.2.3.2.5 | Toteutus | 100d? | 2011-06-13 | 2011-10-28 | 153d | start no earlier than 2011-06-13 | Eduix koodaajat | 800h |
| 117 | 1.2.2.3.2.6 | Testaus | 14d? | 2011-11-01 | 2011-11-18 | 138d | start no earlier than 2011-11-01 |  |  |
| 118 | 1.2.2.3.2.7 | Pilotointi | 45d? | 2011-11-21 | 2012-01-23 | 93d | start no earlier than 2011-11-21 |  |  |
| 119 | 1.2.2.3.3 | **Opetustapahtumien muokkaus (opetuspäiväkirjat, opetustapahtuman peruuttaminen yms.)** | 471d? | 2010-04-01 | 2012-01-23 | 93d |  |  | 800h |
| 120 | 1.2.2.3.3.1 | Määrittely | 217d? | 2010-04-01 | 2011-01-31 | 347d | start no earlier than 2010-04-01 |  |  |
| 121 | 1.2.2.3.3.2 | Suunnittelu | 59d? | 2011-02-01 | 2011-04-22 | 288d | start no earlier than 2011-02-01 |  |  |
| 122 | 1.2.2.3.3.3 | Demo | 20d? | 2011-04-25 | 2011-05-20 | 268d | start no earlier than 2011-04-25 |  |  |
| 123 | 1.2.2.3.3.4 | Hyväksyntä | 15d? | 2011-05-23 | 2011-06-10 | 253d | start no earlier than 2011-05-23 |  |  |
| 124 | 1.2.2.3.3.5 | Toteutus | 100d? | 2011-06-13 | 2011-10-28 | 153d | start no earlier than 2011-06-13 | Eduix koodaajat | 800h |
| 125 | 1.2.2.3.3.6 | Testaus | 14d? | 2011-11-01 | 2011-11-18 | 138d | start no earlier than 2011-11-01 |  |  |
| 126 | 1.2.2.3.3.7 | Pilotointi | 45d? | 2011-11-21 | 2012-01-23 | 93d | start no earlier than 2011-11-21 |  |  |

| ID | WBS | Task | Duration | Start | Finish | Total slack | Constraint | Resources | Work |
| --- | --- | --- | --- | --- | --- | --- | --- | --- | --- |
| 127 | 1.2.2.3.4 | **Opiskelijan hyväksyminen toteutukselle ja arvosanojen antaminen** | 471d? | 2010-04-01 | 2012-01-23 | 93d |  |  | 800h |
| 128 | 1.2.2.3.4.1 | Määrittely | 217d? | 2010-04-01 | 2011-01-31 | 347d | start no earlier than 2010-04-01 |  |  |
| 129 | 1.2.2.3.4.2 | Suunnittelu | 59d? | 2011-02-01 | 2011-04-22 | 288d | start no earlier than 2011-02-01 |  |  |
| 130 | 1.2.2.3.4.3 | Demo | 20d? | 2011-04-25 | 2011-05-20 | 268d | start no earlier than 2011-04-25 |  |  |
| 131 | 1.2.2.3.4.4 | Hyväksyntä | 15d? | 2011-05-23 | 2011-06-10 | 253d | start no earlier than 2011-05-23 |  |  |
| 132 | 1.2.2.3.4.5 | Toteutus | 100d? | 2011-06-13 | 2011-10-28 | 153d | start no earlier than 2011-06-13 | Eduix koodaajat | 800h |
| 133 | 1.2.2.3.4.6 | Testaus | 14d? | 2011-11-01 | 2011-11-18 | 138d | start no earlier than 2011-11-01 |  |  |
| 134 | 1.2.2.3.4.7 | Pilotointi | 45d? | 2011-11-21 | 2012-01-23 | 93d | start no earlier than 2011-11-21 |  |  |
| 135 | 1.2.2.3.5 | **Seuranta-, raportointi ja julkaisupalvelut** | 471d? | 2010-04-01 | 2012-01-23 | 93d |  |  | 800h |
| 136 | 1.2.2.3.5.1 | Määrittely | 217d? | 2010-04-01 | 2011-01-31 | 347d | start no earlier than 2010-04-01 |  |  |
| 137 | 1.2.2.3.5.2 | Suunnittelu | 59d? | 2011-02-01 | 2011-04-22 | 288d | start no earlier than 2011-02-01 |  |  |
| 138 | 1.2.2.3.5.3 | Demo | 20d? | 2011-04-25 | 2011-05-20 | 268d | start no earlier than 2011-04-25 |  |  |
| 139 | 1.2.2.3.5.4 | Hyväksyntä | 15d? | 2011-05-23 | 2011-06-10 | 253d | start no earlier than 2011-05-23 |  |  |
| 140 | 1.2.2.3.5.5 | Toteutus | 100d? | 2011-06-13 | 2011-10-28 | 153d | start no earlier than 2011-06-13 | Eduix koodaajat | 800h |
| 141 | 1.2.2.3.5.6 | Testaus | 14d? | 2011-11-01 | 2011-11-18 | 138d | start no earlier than 2011-11-01 |  |  |
| 142 | 1.2.2.3.5.7 | Pilotointi | 45d? | 2011-11-21 | 2012-01-23 | 93d | start no earlier than 2011-11-21 |  |  |
| 143 | 1.3 | **3. Vaihe** | 219d? | 2011-07-29 | 2012-05-31 | 0d |  |  |  |
| 144 | 1.3.1 | Lopputestaus ja virheiden korjaus | 66d? | 2011-08-01 | 2011-10-31 | 152d | finish no earlier than 2011-10-31 |  |  |
| 145 | 1.3.2 | Koulutusohjelmien pilotointi | 110d? | 2011-07-29 | 2011-12-30 | 109d | finish no earlier than 2011-12-30 |  |  |
| 146 | 1.3.3 | Metropolia henkilökunnan koulutus | 174d? | 2011-09-30 | 2012-05-31 | 0d | finish no earlier than 2012-05-31 |  |  |
| 147 | 1.3.4 | Kaikkien palveluiden käyttöönotto | 131d? | 2011-11-30 | 2012-05-31 | 0d | finish no earlier than 2012-05-31 |  |  |
